# Proyecto WS Caroní

Schedule from MS Project, 2006-11-17 to 2007-01-02.
Globalwebtek Venezuela C.A.

## Calendars

- Estándar: Mon-Fri 08:00-12:00, 13:00-17:00; Sat-Sun off. Exceptions (off unless hours are given): 2006-12-25, 2007-01-01.

## Resources

| Resource |
| --- |
| GP |
| R1 |
| D1 |
| OP |
| KN |
| R2 |
| BC |

## Schedule

| ID | WBS | Task | Type | Duration | Start | Finish | Predecessors | Total slack | Free slack | Constraint | Resources | Work |
| --- | --- | --- | --- | --- | --- | --- | --- | --- | --- | --- | --- | --- |
| 1 | 1 | **Proyecto WebSite Caroní** |  | 30.46d | 2006-11-17 09:00 | 2007-01-02 13:41 |  | 0d |  |  |  | 255.3h |
| 2 | 1.1 | **Inicio** |  | 0.25d | 2006-11-17 09:00 | 2006-11-17 11:00 |  | 30.21d |  |  |  | 4h |
| 3 | 1.1.1 | Reunión Kickoff |  | 0.25d | 2006-11-17 09:00 | 2006-11-17 11:00 |  | 29.62d |  | start no earlier than 2006-11-17 09:00 | GP; D1 | 4h |
| 4 | 1.2 | **Especificación de Requerimientos** |  | 8.38d | 2006-11-29 14:00 | 2006-12-11 17:00 |  | 3.42d |  |  |  | 20h |
| 5 | 1.2.1 | **Levantamiento de Información** |  | 4.88d | 2006-11-29 14:00 | 2006-12-06 12:00 |  | 3.42d |  |  |  | 12h |
| 6 | 1.2.1.1 | Sesión de trabajo # 1 |  | 0.38d | 2006-11-29 14:00 | 2006-11-29 19:00 |  | 3.42d | 0d | finish no earlier than 2006-11-29 19:00 | GP; D1 | 6h |
| 7 | 1.2.1.2 | Sesión de trabajo # 2 |  | 0.38d | 2006-12-06 09:00 | 2006-12-06 12:00 |  | 16.5d |  | start no earlier than 2006-12-06 09:00 | GP; D1 | 6h |
| 8 | 1.2.2 | Elaboración del Informe Especificación de Req. |  | 7d | 2006-11-30 08:00 | 2006-12-08 17:00 | 6 | 3.42d | 0d | start no earlier than 2006-11-29 08:00 | GP [10.7%] | 6h |
| 9 | 1.2.3 | Entrega al Equipo de BC para su revisión | milestone | 0d | 2006-12-08 17:00 | 2006-12-08 17:00 | 8 | 3.42d | 0d | start no earlier than 2006-12-01 08:00 | GP |  |
| 10 | 1.2.4 | Revisión por parte del Equipo de Proyecto BC | milestone | 0d | 2006-12-08 17:00 | 2006-12-08 17:00 | 9 | 3.42d | 0d |  | BC |  |
| 11 | 1.2.5 | Recepción de ajustes recomendados al Informe | milestone | 0d | 2006-12-08 17:00 | 2006-12-08 17:00 | 10 | 3.42d | 0d |  |  |  |
| 12 | 1.2.6 | Ajustes al Informe Especificación de Requerimientos |  | 1d | 2006-12-11 08:00 | 2006-12-11 17:00 | 11 | 3.42d | 0d |  | GP [25%] | 2h |
| 13 | 1.2.7 | Entrega de Especificación de Req. para aprobación | milestone | 0d | 2006-12-11 17:00 | 2006-12-11 17:00 | 12 | 3.42d | 0d | start no earlier than 2006-12-07 08:00 | GP |  |
| 14 | 1.2.8 | Aprobación del Informe Especificación de Requerimientos | milestone | 0d | 2006-12-11 17:00 | 2006-12-11 17:00 | 13 | 3.42d | 0d | start no earlier than 2006-09-15 08:00 | BC |  |
| 15 | 1.3 | Informe Especificación de Requerimientos Aprobado | milestone | 0d | 2006-12-11 17:00 | 2006-12-11 17:00 | 14 | 3.42d | 0d |  |  |  |
| 16 | 1.4 | **Diseño** |  | 5.12d | 2006-11-30 08:00 | 2006-12-07 09:00 |  | 16.46d |  |  |  | 12h |
| 17 | 1.4.1 | Elaboración propuesta de diseño |  | 3.33d | 2006-11-30 08:00 | 2006-12-05 10:40 | 6 | 18d | 0d |  | D1 [37.5%] | 10h |
| 18 | 1.4.2 | Presentación al Cliente |  | 0.25d | 2006-12-05 10:40 | 2006-12-05 13:40 | 17 | 18d |  |  | D1 | 2h |
| 19 | 1.4.3 | Aprobación por parte del Cliente | milestone | 0d | 2006-12-07 09:00 | 2006-12-07 09:00 |  | 16.46d | 0d | start no earlier than 2006-12-07 09:00 | BC |  |
| 20 | 1.5 | Propuesta de Diseño Aprobada | milestone | 0d | 2006-12-07 09:00 | 2006-12-07 09:00 | 19 | 15.88d |  |  |  |  |
| 21 | 1.6 | Incorporación diseño aprobado en WiB3 |  | 3d | 2006-11-17 09:00 | 2006-11-22 09:00 |  | 27.46d |  |  | D1 | 24h |
| 22 | 1.7 | **Configuración aplicaciones** |  | 11.79d | 2006-12-06 09:00 | 2006-12-21 16:18 |  | 3.42d |  |  |  | 135.3h |
| 23 | 1.7.1 | Homologación look and feel aplicación 04600 |  | 0.5d | 2006-12-06 09:00 | 2006-12-06 14:00 |  | 3.38d |  | start no earlier than 2006-12-06 09:00 | R1 | 4h |
| 24 | 1.7.2 | **Aplicación Planificador Financiero** |  | 5.42d | 2006-12-12 08:00 | 2006-12-19 11:24 | 23 | 2.76d |  |  | GP | 89.4h |
| 25 | 1.7.2.1 | Análsis y diseño |  | 0.12d | 2006-12-12 08:00 | 2006-12-12 09:00 | 15 | 2.76d | 0d |  | R1; GP; KN | 3h |
| 26 | 1.7.2.2 | Construcción |  | 5d | 2006-12-12 09:00 | 2006-12-19 09:00 | 25 | 2.76d | 0d |  | R1 | 40h |
| 27 | 1.7.2.3 | Pruebas internas |  | 0.3d | 2006-12-19 09:00 | 2006-12-19 11:24 | 26 | 2.76d | 0d |  | GP; R1 [50%] | 3h |

| ID | WBS | Task | Type | Duration | Start | Finish | Predecessors | Total slack | Free slack | Constraint | Resources | Work |
| --- | --- | --- | --- | --- | --- | --- | --- | --- | --- | --- | --- | --- |
| 28 | 1.7.3 | **Aplicación Contacto** |  | 2.49d | 2006-12-19 11:24 | 2006-12-21 16:18 |  | 3.42d | 0d |  | GP | 41.9h |
| 29 | 1.7.3.1 | Análsis y diseño |  | 0.19d | 2006-12-19 11:24 | 2006-12-19 13:54 | 27 | 3.42d | 0d |  | GP; KN; R1 | 3h |
| 30 | 1.7.3.2 | Construcción |  | 2d | 2006-12-19 13:54 | 2006-12-21 13:54 | 29 | 3.42d | 0d |  | R1 | 16h |
| 31 | 1.7.3.3 | Pruebas internas |  | 0.3d | 2006-12-21 13:54 | 2006-12-21 16:18 | 30 | 3.42d | 0d |  | GP; R1 [50%] | 3h |
| 32 | 1.8 | Integración aplicaciones - WiB3 |  | 1.5d | 2006-12-21 16:18 | 2006-12-26 11:18 | 28 | 4.17d |  |  | R1 | 12h |
| 33 | 1.9 | **Pruebas de Certificación** |  | 0.25d | 2006-12-21 16:18 | 2006-12-22 09:18 |  | 3.42d |  |  |  | 2h |
| 34 | 1.9.1 | Preparación Plan de Pruebas |  | 0.25d | 2006-12-21 16:18 | 2006-12-22 09:18 | 31 | 3.42d | 0d |  | GP | 2h |
| 35 | 1.9.2 | Pruebas de Certificación | milestone | 0d | 2006-12-22 09:18 | 2006-12-22 09:18 | 34 | 3.42d | 0d |  | BC |  |
| 36 | 1.10 | Documentación |  | 2.67d | 2006-12-22 09:18 | 2006-12-27 15:38 | 35 | 2.76d |  |  | GP [25%]; R1 [50%] | 8h |
| 37 | 1.11 | **Puesta en Marcha** |  | 0.75d | 2006-12-22 09:18 | 2006-12-22 16:18 |  | 4.67d |  |  |  | 8h |
| 38 | 1.11.1 | Adiestramiento |  | 0.25d | 2006-12-22 09:18 | 2006-12-22 11:18 | 35 | 4.67d | 0d |  | D1; GP | 4h |
| 39 | 1.11.2 | Implantación en producción |  | 0.5d | 2006-12-22 11:18 | 2006-12-22 16:18 | 38 | 4.67d |  |  | OP | 4h |
| 40 | 1.12 | Gerencia de Proyectos |  | 30.46d | 2006-11-17 09:00 | 2007-01-02 13:41 |  | 0d |  | start no earlier than 2006-11-17 09:00 | GP [12.3%] | 30h |
